# HRA Project Plan

Schedule from MS Project, 2011-10-31 to 2012-03-20, A marks actual dates.
Microsoft

## Calendars

- Standard: Mon-Fri 08:00-12:00, 13:00-17:00; Sat-Sun off. Exceptions (off unless hours are given): 2011-11-24 (Thanksgiving Day), 2011-11-25 (Thanksgiving Friday), 2011-12-23 (Special MIT Holiday 1), 2011-12-26 (Christmas Day Observed), 2011-12-30 (Special MIT Holiday 2), 2012-01-02 (New Years Day Observed), 2012-01-16 (Martin Luther King Birthday), 2012-02-20 (Presidents Day).

## Resources

| Resource |
| --- |
| Ross |
| Jonathan |
| Robin |

## Schedule

| ID | WBS | Task | Type | Duration | Start | Finish | Predecessors | Complete | Remaining | Total slack | Free slack | Constraint | Resources | Work | Actual work |
| --- | --- | --- | --- | --- | --- | --- | --- | --- | --- | --- | --- | --- | --- | --- | --- |
| 1 | 1 | **Housing Replacement Analysis Project** |  | 94d | 2011-10-31 A | 2012-03-20 |  | 43% | 53.43d | 0d |  |  |  | 884h | 318h |
| 2 | 1.1 | Project Kickoff Meeting |  | 1d | 2011-10-31 | 2011-10-31 |  |  |  | 33.67d | 3d |  |  |  |  |
| 3 | 1.2 | **Discovery Phase (as-is)** |  | 90d | 2011-11-04 A | 2012-03-20 |  | 44% | 50.69d | 0d |  |  |  | 884h | 318h |
| 4 | 1.2.1 | **Business Justification** |  | 20d | 2011-11-04 A | 2011-12-06 A | 2 | 100% |  |  |  |  |  | 136h | 136h |
| 5 | 1.2.1.1 | Write Business Justification |  | 10d | 2011-11-14 A | 2011-11-25 A | 6 | 100% |  |  |  | start no earlier than 2011-11-01 | Jonathan | 80h | 80h |
| 6 | 1.2.1.2 | Review Business Justification |  | 6d | 2011-11-04 A | 2011-11-11 A |  | 100% |  |  |  | finish no earlier than 2011-11-11 | Jonathan | 48h | 48h |
| 7 | 1.2.1.3 | Obtain Approval from Project Team |  | 1d | 2011-11-29 A | 2011-11-29 A | 5, 6 | 100% |  |  |  | start no earlier than 2011-11-29 | Jonathan | 8h | 8h |
| 8 | 1.2.1.4 | Obtain Approval from Project Sponsors | milestone | 0d | 2011-12-06 A | 2011-12-06 A | 7 | 100% |  |  |  | start no earlier than 2011-12-06 | Jonathan |  |  |
| 9 | 1.2.1.5 | Business Justification completed | milestone | 0d | 2011-12-06 A | 2011-12-06 A | 8 | 100% |  |  |  |  | Jonathan |  |  |
| 10 | 1.2.2 | **Project Scope Document** |  | 19d | 2011-11-07 A | 2011-12-06 A | 2 | 100% |  |  |  |  |  | 56h | 56h |
| 11 | 1.2.2.1 | Write Project Scope Document |  | 5d | 2011-11-07 A | 2011-11-11 A |  | 100% |  |  |  | finish no earlier than 2011-11-11 | Jonathan | 40h | 40h |
| 12 | 1.2.2.2 | Review Project Scope Document |  | 1d | 2011-11-18 A | 2011-11-18 A | 11 | 100% |  |  |  | finish no earlier than 2011-11-18 | Jonathan | 8h | 8h |
| 13 | 1.2.2.3 | Obtain Approval from Project Team |  | 1d | 2011-11-29 A | 2011-11-29 A |  | 100% |  |  |  | start no earlier than 2011-11-29 | Jonathan | 8h | 8h |
| 14 | 1.2.2.4 | Obtain Approval from Project Sponsors | milestone | 0d | 2011-12-06 A | 2011-12-06 A |  | 100% |  |  |  | start no earlier than 2011-12-06 | Jonathan |  |  |
| 15 | 1.2.2.5 | Project Scope completed | milestone | 0d | 2011-12-06 A | 2011-12-06 A |  | 100% |  |  |  | start no earlier than 2011-12-06 | Jonathan |  |  |
| 16 | 1.2.3 | **As-Is Process Maps** |  | 65d | 2011-11-29 A | 2012-03-06 | 4, 10 | 25% | 48.75d | 10d |  |  |  | 452h | 126h |
| 17 | 1.2.3.1 | System (IS&T) |  | 15d | 2011-11-29 A | 2011-12-19 |  | 82% | 2.75d | 6d |  |  | Ross; Robin; Jonathan | 192h | 126h |
| 18 | 1.2.3.2 | **Housing / Lottery** |  | 31d | 2012-01-03 | 2012-02-15 | 17 |  |  | 0d |  |  |  | 164h |  |
| 19 | 1.2.3.2.1 | Freshman (new to the Institute) |  | 2d | 2012-01-03 | 2012-01-04 | 17 |  |  | 0d |  |  | Ross [25%] | 4h |  |
| 20 | 1.2.3.2.2 | Upperclassman |  | 2d | 2012-01-05 | 2012-01-06 | 19 |  |  | 0d |  |  | Ross | 16h |  |
| 21 | 1.2.3.2.3 | FSILG |  | 2d | 2012-01-09 | 2012-01-10 | 20 |  |  | 0d |  |  | Ross | 16h |  |
| 22 | 1.2.3.2.4 | Off Campus Students |  | 2d | 2012-01-11 | 2012-01-12 | 21 |  |  | 0d |  |  | Ross | 16h |  |
| 23 | 1.2.3.2.5 | Graduate Students |  | 2d | 2012-01-13 | 2012-01-30 | 22 |  |  | 0d |  |  | Ross | 16h |  |
| 24 | 1.2.3.2.6 | Summer Students |  | 2d | 2012-01-31 | 2012-02-01 | 23 |  |  | 0d |  |  | Ross | 16h |  |
| 25 | 1.2.3.2.7 | Post-Doctoral / Faculty |  | 2d | 2012-02-02 | 2012-02-03 | 24 |  |  | 0d |  |  | Ross | 16h |  |
| 26 | 1.2.3.2.8 | Young Students (Legal Minors) |  | 2d | 2012-02-06 | 2012-02-07 | 25 |  |  | 0d |  |  | Ross | 16h |  |
| 27 | 1.2.3.2.9 | Outside, Non Affiliated Groups |  | 2d | 2012-02-08 | 2012-02-09 | 26 |  |  | 0d |  |  | Ross | 16h |  |
| 28 | 1.2.3.2.10 | MIT - Affiliated Groups |  | 2d | 2012-02-10 | 2012-02-13 | 27 |  |  | 0d |  |  | Ross | 16h |  |
| 29 | 1.2.3.2.11 | Visitors |  | 2d | 2012-02-14 | 2012-02-15 | 28 |  |  | 0d |  |  | Ross | 16h |  |

| ID | WBS | Task | Type | Duration | Start | Finish | Predecessors | Total slack | Resources | Work |
| --- | --- | --- | --- | --- | --- | --- | --- | --- | --- | --- |
| 30 | 1.2.3.3 | **Housing Stakeholder** |  | 12d | 2012-02-16 | 2012-03-05 |  | 0d |  | 96h |
| 31 | 1.2.3.3.1 | Housing / DS Finance, Billing, & Assessment |  | 2d | 2012-02-16 | 2012-02-17 | 29 | 0d | Ross | 16h |
| 32 | 1.2.3.3.2 | Registrar's Office |  | 2d | 2012-02-21 | 2012-02-22 | 31 | 0d | Ross | 16h |
| 33 | 1.2.3.3.3 | Student Financial Services |  | 2d | 2012-02-23 | 2012-02-24 | 32 | 0d | Ross | 16h |
| 34 | 1.2.3.3.4 | Card Office |  | 2d | 2012-02-27 | 2012-02-28 | 33 | 0d | Ross | 16h |
| 35 | 1.2.3.3.5 | Security and Emergency Office |  | 2d | 2012-02-29 | 2012-03-01 | 34 | 0d | Ross | 16h |
| 36 | 1.2.3.3.6 | Campus Dining |  | 2d | 2012-03-02 | 2012-03-05 | 35 | 0d | Ross | 16h |
| 37 | 1.2.3.4 | As-Is Process Maps completed | milestone | 0d | 2012-03-06 | 2012-03-06 | 18, 30FS+1d | 10d |  |  |
| 38 | 1.2.4 | Review with Project Team, Stakeholders |  | 10d | 2012-03-06 | 2012-03-19 | 36 | 0d | Ross; Robin; Jonathan | 240h |
| 39 | 1.2.5 | Discovery Phase Completed | milestone | 0d | 2012-03-20 | 2012-03-20 | 38FS+1d | 0d |  |  |
| 40 | 1.3 | Define Phase | milestone | 0d | 2012-03-20 | 2012-03-20 | 3 | 0d |  |  |
| 41 | 1.4 | Design Phase | milestone | 0d | 2012-03-20 | 2012-03-20 | 40 | 0d |  |  |
